# HAMIYAN SANAT

Schedule from MS Project, 2025-02-20 to 2025-05-25, 9 hours a day.

## Calendars

- HAMIYAN SANAT: Mon-Thu 08:00-12:00, 13:00-18:00; Fri off; Sat-Sun 08:00-12:00, 13:00-18:00.

## Schedule

| ID | WBS | Task | Duration | Start | Finish | Predecessors | Total slack | Free slack | شروع | پایان |
| --- | --- | --- | --- | --- | --- | --- | --- | --- | --- | --- |
| 1 | 1 | **Engineering & Designing** | 67d | 2025-02-20 | 2025-05-08 |  | 0d |  | 1403/12/2 | 1404/2/18 |
| 2 | 1.1 | **Vessels 1&2** | 67d | 2025-02-20 | 2025-05-08 |  | 0d |  | 1403/12/2 | 1404/2/18 |
| 3 | 1.1.1 | Engineering & Designing | 67d | 2025-02-20 | 2025-05-08 |  | 0d |  | 1403/12/2 | 1404/2/18 |
| 4 | 2 | **PROCUREMENT** | 4d | 2025-03-04 | 2025-03-08 |  | 0d |  | 1403/12/14 | 1403/12/18 |
| 5 | 2.1 | **Vessels 1&2** | 4d | 2025-03-04 | 2025-03-08 |  | 0d |  | 1403/12/14 | 1403/12/18 |
| 6 | 2.1.1 | **Mechanical** | 4d | 2025-03-04 | 2025-03-08 | 3SS+10d | 0d |  | 1403/12/14 | 1403/12/18 |
| 7 | 2.1.1.1 | Purchase order | 1d | 2025-03-04 | 2025-03-04 |  | 0d |  | 1403/12/14 | 1403/12/14 |
| 8 | 2.1.1.2 | Inspection | 2d | 2025-03-05 | 2025-03-06 | 7 | 0d |  | 1403/12/15 | 1403/12/16 |
| 9 | 2.1.1.3 | Delivery at site | 1d | 2025-03-08 | 2025-03-08 | 8 | 0d |  | 1403/12/18 | 1403/12/18 |
| 10 | 2.1.2 | **Paint Material** | 4d | 2025-03-04 | 2025-03-08 | 3SS+10d | 0d |  | 1403/12/14 | 1403/12/18 |
| 11 | 2.1.2.1 | Purchase order | 1d | 2025-03-04 | 2025-03-04 |  | 0d |  | 1403/12/14 | 1403/12/14 |
| 12 | 2.1.2.2 | Inspection | 2d | 2025-03-05 | 2025-03-06 | 11 | 0d |  | 1403/12/15 | 1403/12/16 |
| 13 | 2.1.2.3 | Delivery at site | 1d | 2025-03-08 | 2025-03-08 | 12 | 0d |  | 1403/12/18 | 1403/12/18 |
| 14 | 3 | **CONSTRUCTION** | 52d | 2025-03-09 | 2025-05-07 |  | 0d |  | 1403/12/19 | 1404/2/17 |
| 15 | 3.1 | **Vessels 1&2** | 52d | 2025-03-09 | 2025-05-07 |  | 0d |  | 1403/12/19 | 1404/2/17 |
| 16 | 3.1.1 | **Mechanical** | 45d | 2025-03-09 | 2025-04-29 | 5 | 0d |  | 1403/12/19 | 1404/2/9 |
| 17 | 3.1.1.1 | **Elliptical Head** | 19d | 2025-03-09 | 2025-03-30 |  | 0d |  | 1403/12/19 | 1404/1/10 |
| 18 | 3.1.1.1.1 | **Elliptical Head 1 & 2** | 19d | 2025-03-09 | 2025-03-30 |  | 0d |  | 1403/12/19 | 1404/1/10 |
| 19 | 3.1.1.1.1.1 | Cutting | 3d | 2025-03-09 | 2025-03-11 |  | 0d |  | 1403/12/19 | 1403/12/21 |
| 20 | 3.1.1.1.1.2 | Grinding | 2d | 2025-03-12 | 2025-03-13 | 19 | 0d |  | 1403/12/22 | 1403/12/23 |
| 21 | 3.1.1.1.1.3 | Beveling | 2d | 2025-03-15 | 2025-03-16 | 20 | 0d |  | 1403/12/25 | 1403/12/26 |
| 22 | 3.1.1.1.1.4 | Fitup | 2d | 2025-03-17 | 2025-03-18 | 21 | 0d |  | 1403/12/27 | 1403/12/28 |
| 23 | 3.1.1.1.1.5 | Head manufacturing | 10d | 2025-03-19 | 2025-03-30 | 22 | 0d |  | 1403/12/29 | 1404/1/10 |
| 24 | 3.1.1.2 | **Shell** | 8d | 2025-03-31 | 2025-04-08 |  | 0d |  | 1404/1/11 | 1404/1/19 |
| 25 | 3.1.1.2.1 | **Shell Plate Course1** | 8d | 2025-03-31 | 2025-04-08 |  | 40d |  | 1404/1/11 | 1404/1/19 |
| 26 | 3.1.1.2.1.1 | Cutting | 1d | 2025-03-31 | 2025-03-31 | 23 | 40d | 0d | 1404/1/11 | 1404/1/11 |
| 27 | 3.1.1.2.1.2 | Grinding | 1d | 2025-04-01 | 2025-04-01 | 26 | 40d | 0d | 1404/1/12 | 1404/1/12 |
| 28 | 3.1.1.2.1.3 | Beveling | 1d | 2025-04-02 | 2025-04-02 | 27 | 40d | 0d | 1404/1/13 | 1404/1/13 |
| 29 | 3.1.1.2.1.4 | Rolling | 3d | 2025-04-03 | 2025-04-06 | 28 | 40d | 0d | 1404/1/14 | 1404/1/17 |
| 30 | 3.1.1.2.1.5 | Welding | 2d | 2025-04-07 | 2025-04-08 | 29 | 40d |  | 1404/1/18 | 1404/1/19 |

| ID | WBS | Task | Duration | Start | Finish | Predecessors | Total slack | Free slack | شروع | پایان |
| --- | --- | --- | --- | --- | --- | --- | --- | --- | --- | --- |
| 31 | 3.1.1.2.2 | **Shell Plate Course2** | 8d | 2025-03-31 | 2025-04-08 |  | 0d |  | 1404/1/11 | 1404/1/19 |
| 32 | 3.1.1.2.2.1 | Cutting | 1d | 2025-03-31 | 2025-03-31 | 23 | 0d |  | 1404/1/11 | 1404/1/11 |
| 33 | 3.1.1.2.2.2 | Grinding | 1d | 2025-04-01 | 2025-04-01 | 32 | 0d |  | 1404/1/12 | 1404/1/12 |
| 34 | 3.1.1.2.2.3 | Beveling | 1d | 2025-04-02 | 2025-04-02 | 33 | 0d |  | 1404/1/13 | 1404/1/13 |
| 35 | 3.1.1.2.2.4 | Rolling | 3d | 2025-04-03 | 2025-04-06 | 34 | 0d |  | 1404/1/14 | 1404/1/17 |
| 36 | 3.1.1.2.2.5 | Welding | 2d | 2025-04-07 | 2025-04-08 | 35 | 0d |  | 1404/1/18 | 1404/1/19 |
| 37 | 3.1.1.3 | **Welding Shell to Shell & Shell to Head** | 9d | 2025-04-09 | 2025-04-19 |  | 0d |  | 1404/1/20 | 1404/1/30 |
| 38 | 3.1.1.3.1 | **Fitup of Shell Course 1 to Shell Course 2** | 3d | 2025-04-09 | 2025-04-12 |  | 0d |  | 1404/1/20 | 1404/1/23 |
| 39 | 3.1.1.3.1.1 | Fitup | 1d | 2025-04-09 | 2025-04-09 | 36 | 0d |  | 1404/1/20 | 1404/1/20 |
| 40 | 3.1.1.3.1.2 | Welding | 2d | 2025-04-10 | 2025-04-12 | 39 | 0d |  | 1404/1/21 | 1404/1/23 |
| 41 | 3.1.1.3.2 | **Fitup of Shell Course 1 to Head 2** | 3d | 2025-04-13 | 2025-04-15 |  | 0d |  | 1404/1/24 | 1404/1/26 |
| 42 | 3.1.1.3.2.1 | Fitup | 1d | 2025-04-13 | 2025-04-13 | 40 | 0d |  | 1404/1/24 | 1404/1/24 |
| 43 | 3.1.1.3.2.2 | Welding | 2d | 2025-04-14 | 2025-04-15 | 42 | 0d |  | 1404/1/25 | 1404/1/26 |
| 44 | 3.1.1.3.3 | **Fitup of Shell Course 2 to Head 2** | 3d | 2025-04-16 | 2025-04-19 |  | 0d |  | 1404/1/27 | 1404/1/30 |
| 45 | 3.1.1.3.3.1 | Fitup | 1d | 2025-04-16 | 2025-04-16 | 43 | 0d |  | 1404/1/27 | 1404/1/27 |
| 46 | 3.1.1.3.3.2 | Welding | 2d | 2025-04-17 | 2025-04-19 | 45 | 0d |  | 1404/1/28 | 1404/1/30 |
| 47 | 3.1.1.4 | **Saddle** | 19d | 2025-03-31 | 2025-04-21 |  | 17d |  | 1404/1/11 | 1404/2/1 |
| 48 | 3.1.1.4.1 | Cutting | 1d | 2025-03-31 | 2025-03-31 | 26SS, 32SS | 46d | 0d | 1404/1/11 | 1404/1/11 |
| 49 | 3.1.1.4.2 | Fitup | 1d | 2025-04-01 | 2025-04-01 | 48 | 46d |  | 1404/1/12 | 1404/1/12 |
| 50 | 3.1.1.4.3 | Welding | 2d | 2025-04-20 | 2025-04-21 | 46 | 0d |  | 1404/1/31 | 1404/2/1 |
| 51 | 3.1.1.5 | **Nozzle** | 7d | 2025-04-22 | 2025-04-29 |  | 0d |  | 1404/2/2 | 1404/2/9 |
| 52 | 3.1.1.5.1 | Cutting | 1d | 2025-04-22 | 2025-04-22 | 50 | 0d |  | 1404/2/2 | 1404/2/2 |
| 53 | 3.1.1.5.2 | Beveling | 1d | 2025-04-23 | 2025-04-23 | 52 | 0d |  | 1404/2/3 | 1404/2/3 |
| 54 | 3.1.1.5.3 | Fitup | 2d | 2025-04-24 | 2025-04-26 | 53 | 0d |  | 1404/2/4 | 1404/2/6 |
| 55 | 3.1.1.5.4 | Welding | 3d | 2025-04-27 | 2025-04-29 | 54 | 0d |  | 1404/2/7 | 1404/2/9 |

| ID | WBS | Task | Duration | Start | Finish | Predecessors | Total slack | شروع | پایان |
| --- | --- | --- | --- | --- | --- | --- | --- | --- | --- |
| 56 | 3.1.2 | **Painting** | 4d | 2025-05-04 | 2025-05-07 |  | 0d | 1404/2/14 | 1404/2/17 |
| 57 | 3.1.2.1 | **External Painting** | 4d | 2025-05-04 | 2025-05-07 |  | 0d | 1404/2/14 | 1404/2/17 |
| 58 | 3.1.2.1.1 | Blasting | 1d | 2025-05-04 | 2025-05-04 | 64 | 0d | 1404/2/14 | 1404/2/14 |
| 59 | 3.1.2.1.2 | Painting | 3d | 2025-05-05 | 2025-05-07 | 58 | 0d | 1404/2/15 | 1404/2/17 |
| 60 | 4 | **PRE COMMISSIONING & COMMISSIONING** | 8d | 2025-04-30 | 2025-05-08 |  | 0d | 1404/2/10 | 1404/2/18 |
| 61 | 4.1 | **Vessels 1&2** | 8d | 2025-04-30 | 2025-05-08 |  | 0d | 1404/2/10 | 1404/2/18 |
| 62 | 4.1.1 | **Pre Commissioning** | 3d | 2025-04-30 | 2025-05-03 |  | 0d | 1404/2/10 | 1404/2/13 |
| 63 | 4.1.1.1 | Hydrostatic test | 1d | 2025-04-30 | 2025-04-30 | 55 | 0d | 1404/2/10 | 1404/2/10 |
| 64 | 4.1.1.2 | N2 Filling Procedure | 2d | 2025-05-01 | 2025-05-03 | 63 | 0d | 1404/2/11 | 1404/2/13 |
| 65 | 4.1.2 | **COMMISSIONING** | 1d | 2025-05-08 | 2025-05-08 |  | 0d | 1404/2/18 | 1404/2/18 |
| 66 | 4.1.2.1 | Tank Delivery to client | 1d | 2025-05-08 | 2025-05-08 | 59 | 0d | 1404/2/18 | 1404/2/18 |
| 67 | 5 | **FINAL BOOK** | 14d | 2025-05-10 | 2025-05-25 |  | 0d | 1404/2/20 | 1404/3/4 |
| 68 | 5.1 | **Vessels 1&2** | 14d | 2025-05-10 | 2025-05-25 |  | 0d | 1404/2/20 | 1404/3/4 |
| 69 | 5.1.1 | Final Book | 14d | 2025-05-10 | 2025-05-25 | 66 | 0d | 1404/2/20 | 1404/3/4 |
